# Сопроводительный файл

Schedule from MS Project, 2002-01-10 to 2002-04-19, status date 2002-02-10.
MS Project 2002
Планирование ресурсов - 3. Настройка параметров. Определение назначений.

## Calendars

- Standard: Mon-Thu 09:00-12:00, 13:00-18:00; Fri 08:00-12:00, 13:00-17:00; Sat-Sun off. Exceptions (off unless hours are given): 2002-02-25, 2002-03-08.

## Resources

| Resource |
| --- |
| Иванов |
| Бумага для типографии |
| Фотомодель по контракту |
| Терехов |
| Тарарухин |
| Борисов |
| Семенов |
| Бурков |
| Лимонов |
| Улендеева |
| Сергеева |
| Жуков |
| Еремин |
| Ураганов |
| Баранов |
| Козлов |
| Васин |
| Уваров |
| Галкина |
| Сидоров |
| Петров |
| Краска для вывода пленок |

## Schedule

| ID | WBS | Task | Type | Duration | Start | Finish | Predecessors | Total slack | Free slack | Constraint |
| --- | --- | --- | --- | --- | --- | --- | --- | --- | --- | --- |
| 1 | МАЙ//001 | **Планирование номера** |  | 13d | 2002-01-10 | 2002-01-28 |  | 0d |  |  |
| 2 | МАЙ//001.A | Сбор предложений от авторов |  | 5d | 2002-01-10 | 2002-01-16 |  | 0d |  |  |
| 3 | МАЙ//001.B | Подготовка плана номера |  | 3d | 2002-01-17 | 2002-01-21 | 2 | 0d |  |  |
| 4 | МАЙ//001.C | Предварительная редколлегия |  | 1d | 2002-01-22 | 2002-01-22 | 3 | 0d |  |  |
| 5 | МАЙ//001.D | Доработка планов с учетом замечаний |  | 3d | 2002-01-23 | 2002-01-25 | 4 | 0d |  |  |
| 6 | МАЙ//001.E | Редколлегия |  | 1d | 2002-01-28 | 2002-01-28 | 5 | 0d |  |  |
| 7 | МАЙ//001.F | План номера утвержден | milestone | 0d | 2002-01-28 | 2002-01-28 | 6 | 0d |  |  |
| 8 | МАЙ//002 | **Подготовка материалов** |  | 35d | 2002-01-29 | 2002-03-20 | 7 | 0d |  |  |
| 9 | МАЙ//002.A | **Подготовка обложки** |  | 29.88d | 2002-02-01 | 2002-03-18 |  | 0d |  |  |
| 10 | МАЙ//002.A-a | Отбор модели |  | 2d | 2002-02-01 | 2002-02-05 |  | 0d |  | must start on 2002-02-01 |
| 11 | МАЙ//002.A-b | Фотосъемка модели |  | 4d | 2002-02-05 | 2002-02-11 | 10 | 27.88d | 20.88d |  |
| 12 | МАЙ//002.A-c | Подготовка анонсов материалов номера для обложки |  | 3d | 2002-03-11 | 2002-03-13 | 22FS-5% | 7d | 0d |  |
| 13 | МАЙ//002.A-d | Передача рекламных анонсов в предыдущий номер | milestone | 1d | 2002-03-11 | 2002-03-11 | 22FS-5% | 29d |  |  |
| 14 | МАЙ//002.A-e | Верстка обложки |  | 3d | 2002-03-14 | 2002-03-18 | 12, 11 | 7d | 0d |  |
| 15 | МАЙ//002.A-f | Обложка готова | milestone | 0d | 2002-03-18 | 2002-03-18 | 14 | 7d |  |  |
| 16 | МАЙ//002.B | **Подготовка текстов** |  | 35d | 2002-01-29 | 2002-03-20 |  | 0d |  |  |
| 17 | МАЙ//002.B-a | Подготовка редакционных заданий |  | 3d | 2002-01-29 | 2002-01-31 |  | 0d |  |  |
| 18 | МАЙ//002.B-b | Рассылка заданий авторам |  | 2d | 2002-02-01 | 2002-02-04 | 17 | 0d |  |  |
| 19 | МАЙ//002.B-c | Утверждение заданий |  | 4d | 2002-02-05 | 2002-02-08 | 18 | 0d |  |  |
| 20 | МАЙ//002.B-d | Статьи в работе у авторов | milestone | 0d | 2002-02-08 | 2002-02-08 | 19 | 0d |  |  |
| 21 | МАЙ//002.B-e | Статьи поступили в редакцию | milestone | 0d | 2002-02-22 | 2002-02-22 | 20FS+10d | 0d |  |  |
| 22 | МАЙ//002.B-f | Редактирование материалов |  | 16d | 2002-02-26 | 2002-03-20 | 21 | 0d |  |  |
| 23 | МАЙ//002.B-g | Техническое редактирование |  | 14d | 2002-02-28 | 2002-03-20 | 22SS+2d | 0d |  |  |
| 24 | МАЙ//002.B-h | Тексты готовы | milestone | 0d | 2002-03-20 | 2002-03-20 | 23 | 22d |  |  |
| 25 | МАЙ//002.C | Подготовка материалов завершена | milestone | 0d | 2002-03-20 | 2002-03-20 | 23 | 22d |  |  |

Notes:
- 2: Text1: Файл предложений в редакционном формате.
- 3: Text1: План номера в формате XLS с названиями статей от редакторов разделов.
- 4: Text1: Предварительный план номиера обсужден.
- 5: Text1: Планы каждого из редакторов разделов доработаны с учетом замечаний.
- 6: Задания на этот номер должны включать темы: / ·летний отдых; / ·фотокамеры; / ·видеокамеры. / Text1: Окончательный план номера согласован с редакторами разделов и главным редактором.
- 13: Шаблон документа для передачи анонсов.

| ID | WBS | Task | Type | Duration | Start | Finish | Predecessors | Total slack | Free slack | Constraint | Resources | Work |
| --- | --- | --- | --- | --- | --- | --- | --- | --- | --- | --- | --- | --- |
| 26 | МАЙ//003 | **Верстка журнала** |  | 18d | 2002-03-05 | 2002-03-29 |  | 0d |  |  |  |  |
| 27 | МАЙ//003.A | Обработка текста и иллюстраций |  | 14d | 2002-03-05 | 2002-03-25 | 23SS+3d | 0d |  |  |  |  |
| 28 | МАЙ//003.B | Вычитка |  | 14d | 2002-03-11 | 2002-03-28 | 27SS+3d | 15d | 0d |  |  |  |
| 29 | МАЙ//003.C | Сверка |  | 12d | 2002-03-14 | 2002-03-29 | 28SS+3d | 15d |  |  |  |  |
| 30 | МАЙ//003.D | Подготовка оглавления |  | 2d | 2002-03-26 | 2002-03-27 | 27 | 0d |  |  |  |  |
| 31 | МАЙ//003.E | Окончательная сборка |  | 2d | 2002-03-28 | 2002-03-29 | 30, 15 | 0d |  |  |  |  |
| 32 | МАЙ//003.F | Номер сверстан | milestone | 0d | 2002-03-29 | 2002-03-29 | 31 | 0d |  |  |  |  |
| 33 | МАЙ//004 | **Предпечатная подготовка** |  | 15d | 2002-04-01 | 2002-04-19 | 32 | 0d |  |  |  | 78.4h |
| 34 | МАЙ//004.A | Конвертция сверстанного номера в формат Mac |  | 5d | 2002-04-01 | 2002-04-05 |  | 0d |  |  |  |  |
| 35 | МАЙ//004.B | Цветоделение |  | 7d | 2002-04-08 | 2002-04-16 | 34 | 0d |  |  |  |  |
| 36 | МАЙ//004.C | Коррекция |  | 7d | 2002-04-09 | 2002-04-17 | 35SS+1d | 0d |  |  |  |  |
| 37 | МАЙ//004.D | Вывод пленок |  | 7d | 2002-04-10 | 2002-04-19 | 36SS+2d | 0d |  |  | Лимонов [25%]; Бурков [25%]; Борисов [30%]; Тарарухин [30%]; Терехов [30%]; Краска для вывода пленок [300%] | 78.4h |
| 38 | МАЙ//004.E | Номер готов к передаче в типографию | milestone | 0d | 2002-04-19 | 2002-04-19 | 37 | 0d |  | finish no later than 2002-04-20 |  |  |
