# Сопроводительный файл

Schedule from MS Project, 2002-01-10 to 2002-04-09, status date 2002-02-10.
MS Project 2002
Планирование ресурсов - 4. Назначение ресурсов на все задачи.

## Calendars

- Standard: Mon-Thu 09:00-12:00, 13:00-18:00; Fri 08:00-12:00, 13:00-17:00; Sat-Sun off. Exceptions (off unless hours are given): 2002-02-25, 2002-03-08.

## Resources

| Resource |
| --- |
| Иванов |
| Бумага для типографии |
| Фотомодель по контракту |
| Терехов |
| Тарарухин |
| Борисов |
| Семенов |
| Бурков |
| Лимонов |
| Улендеева |
| Сергеева |
| Жуков |
| Еремин |
| Ураганов |
| Баранов |
| Козлов |
| Васин |
| Уваров |
| Галкина |
| Сидоров |
| Петров |
| Краска для вывода пленок |
| Фотопленка |

## Schedule

| ID | WBS | Task | Type | Duration | Start | Finish | Predecessors | Total slack | Free slack | Constraint | Resources | Work |
| --- | --- | --- | --- | --- | --- | --- | --- | --- | --- | --- | --- | --- |
| 1 | МАЙ//001 | **Планирование номера** |  | 11.62d | 2002-01-10 | 2002-01-25 |  | -4.5d | 0d |  |  | 78h |
| 2 | МАЙ//001.A | Сбор предложений от авторов |  | 5d | 2002-01-10 | 2002-01-16 |  | -4.5d | 0d |  | Иванов [25%]; Петров [25%]; Сидоров [25%] | 15h |
| 3 | МАЙ//001.B | Подготовка плана номера |  | 3d | 2002-01-17 | 2002-01-21 | 2 | -4.5d | 0d |  | Иванов [25%]; Петров [25%]; Сидоров [25%]; Уваров [12.5%] | 19h |
| 4 | МАЙ//001.C | Предварительная редколлегия |  | 3h | 2002-01-22 | 2002-01-22 | 3 | -4.5d | 0d |  | Иванов; Петров; Сидоров; Галкина; Уваров | 15h |
| 5 | МАЙ//001.D | Доработка планов с учетом замечаний |  | 3d | 2002-01-22 | 2002-01-25 | 4 | -4.5d | 0d |  | Иванов [25%]; Петров [25%]; Сидоров [25%] | 18h |
| 6 | МАЙ//001.E | Редколлегия |  | 2h | 2002-01-25 | 2002-01-25 | 5 | -4.5d | 0d |  | Иванов; Петров; Сидоров; Галкина [150%]; Уваров | 11h |
| 7 | МАЙ//001.F | План номера утвержден | milestone | 0d | 2002-01-25 | 2002-01-25 | 6 | -4.5d | 0d |  |  |  |
| 8 | МАЙ//002 | **Подготовка материалов** |  | 34.38d | 2002-01-25 | 2002-03-18 | 7 | -4.5d | 0d |  |  | 700.2h |
| 9 | МАЙ//002.A | **Подготовка обложки** |  | 26.62d | 2002-02-01 | 2002-03-13 |  | 0d |  |  |  | 87.4h |
| 10 | МАЙ//002.A-a | Отбор модели |  | 2d | 2002-02-01 | 2002-02-05 |  | 0d |  | must start on 2002-02-01 | Еремин [50%] | 8h |
| 11 | МАЙ//002.A-b | Фотосъемка модели |  | 4d | 2002-02-05 | 2002-02-11 | 10 | 21.38d | 17.62d |  | Жуков [114.3%]; Фотомодель по контракту [57.1%]; Фотопленка [300%] | 41h |
| 12 | МАЙ//002.A-c | Подготовка анонсов материалов номера для обложки |  | 3d | 2002-03-04 | 2002-03-07 | 22FS-5% | 3.75d | 0d |  | Сидоров [70%] | 16.8h |
| 13 | МАЙ//002.A-d | Передача рекламных анонсов в предыдущий номер | milestone | 1d | 2002-03-04 | 2002-03-05 | 22FS-5% | 24.25d |  |  |  |  |
| 14 | МАЙ//002.A-e | Верстка обложки |  | 3d | 2002-03-07 | 2002-03-13 | 12, 11 | 3.75d | 0d |  | Еремин [70%]; Жуков [20%] | 21.6h |
| 15 | МАЙ//002.A-f | Обложка готова | milestone | 0d | 2002-03-13 | 2002-03-13 | 14 | 3.75d |  |  |  |  |
| 16 | МАЙ//002.B | **Подготовка текстов** |  | 34.38d | 2002-01-25 | 2002-03-18 |  | -4.5d | 0d |  |  | 612.8h |
| 17 | МАЙ//002.B-a | Подготовка редакционных заданий |  | 3d | 2002-01-25 | 2002-01-30 |  | -4.5d | 0d |  | Иванов [200%]; Петров [200%]; Сидоров [200%]; Галкина [160%] | 72h |
| 18 | МАЙ//002.B-b | Рассылка заданий авторам |  | 1.38d | 2002-01-30 | 2002-01-31 | 17 | -4.5d | 0d |  | Галкина [33.3%] | 2h |
| 19 | МАЙ//002.B-c | Утверждение заданий авторами |  | 4d | 2002-02-01 | 2002-02-06 | 18 | -4.5d | 0d |  | Галкина [12.5%] | 4h |
| 20 | МАЙ//002.B-d | Статьи в работе у авторов | milestone | 0d | 2002-02-06 | 2002-02-06 | 19 | -4.5d | 0d |  |  |  |
| 21 | МАЙ//002.B-e | Статьи поступили в редакцию | milestone | 0d | 2002-02-20 | 2002-02-20 | 20FS+10d | -4.5d | 0d |  |  |  |
| 22 | МАЙ//002.B-f | Редактирование материалов |  | 13.5d | 2002-02-21 | 2002-03-14 | 21 | -4.5d | 0d |  | Иванов [50%]; Петров [50%]; Сидоров [50%] | 154h |
| 23 | МАЙ//002.B-g | Техническое редактирование |  | 14d | 2002-02-26 | 2002-03-18 | 22SS+2d | -4.5d | 0d |  | Иванов [30%]; Петров [30%]; Сидоров [30%]; Галкина [50%]; Васин; Козлов | 380.8h |
| 24 | МАЙ//002.B-h | Тексты готовы | milestone | 0d | 2002-03-18 | 2002-03-18 | 23 | 16d |  |  |  |  |
| 25 | МАЙ//002.C | Подготовка материалов завершена | milestone | 0d | 2002-03-18 | 2002-03-18 | 23 | 16d |  |  |  |  |

Notes:
- 2: Text1: Файл предложений в редакционном формате.
- 3: Text1: План номера в формате XLS с названиями статей от редакторов разделов.
- 4: Text1: Предварительный план номиера обсужден.
- 5: Text1: Планы каждого из редакторов разделов доработаны с учетом замечаний.
- 6: Задания на этот номер должны включать темы: / ·летний отдых; / ·фотокамеры; / ·видеокамеры. / Text1: Окончательный план номера согласован с редакторами разделов и главным редактором.
- 13: Шаблон документа для передачи анонсов.

| ID | WBS | Task | Type | Duration | Start | Finish | Predecessors | Total slack | Free slack | Constraint | Resources | Work |
| --- | --- | --- | --- | --- | --- | --- | --- | --- | --- | --- | --- | --- |
| 26 | МАЙ//003 | **Верстка журнала** |  | 18d | 2002-03-01 | 2002-03-27 |  | -4.5d | 0d |  |  | 528.4h |
| 27 | МАЙ//003.A | Обработка текста и иллюстраций |  | 14d | 2002-03-01 | 2002-03-21 | 23SS+3d | -4.5d | 0d |  | Сергеева; Улендеева | 224h |
| 28 | МАЙ//003.B | Вычитка |  | 14d | 2002-03-06 | 2002-03-26 | 27SS+3d | 9d | 0d |  | Баранов [50%]; Ураганов [50%] | 112h |
| 29 | МАЙ//003.C | Сверка |  | 12d | 2002-03-12 | 2002-03-27 | 28SS+3d | 9d |  |  | Иванов [30%]; Петров [30%]; Сидоров [30%]; Баранов [50%]; Ураганов [50%] | 182.4h |
| 30 | МАЙ//003.D | Подготовка оглавления |  | 2d | 2002-03-22 | 2002-03-25 | 27 | -4.5d | 0d |  | Сидоров [25%] | 4h |
| 31 | МАЙ//003.E | Окончательная сборка |  | 2d | 2002-03-26 | 2002-03-27 | 30, 15 | -4.5d | 0d |  | Сидоров [62.5%]; Васин [25%] | 6h |
| 32 | МАЙ//003.F | Номер сверстан | milestone | 0d | 2002-03-27 | 2002-03-27 | 31 | -4.5d | 0d |  |  |  |
| 33 | МАЙ//004 | **Предпечатная подготовка** |  | 9d | 2002-03-27 | 2002-04-09 | 32 | -4.5d | 0d |  |  | 318.4h |
| 34 | МАЙ//004.A | Конвертция сверстанного номера в формат Mac |  | 6d | 2002-03-27 | 2002-03-31 |  | -5d | 0d |  | Лимонов [111.1%]; Бурков [111.1%]; Семенов [76.9%] | 80h |
| 35 | МАЙ//004.B | Цветоделение |  | 7d | 2002-03-31 | 2002-04-04 | 34 | -5d | 0d |  | Бурков [20%]; Семенов [20%]; Борисов [25%]; Тарарухин [20%]; Терехов [20%] | 56h |
| 36 | МАЙ//004.C | Коррекция |  | 7d | 2002-04-01 | 2002-04-05 | 35SS+1d | -5d | 0d |  | Лимонов [25%]; Бурков [25%]; Семенов [25%] | 42h |
| 37 | МАЙ//004.D | Вывод пленок |  | 14.38d | 2002-03-28 | 2002-04-09 | 36SS+2d | -5d | 0d | finish no later than 2002-04-09 | Лимонов [34.8%]; Бурков [34.8%]; Борисов [41.8%]; Тарарухин [41.8%]; Терехов [41.8%]; Краска для вывода пленок [17.4%] | 140.4h |
| 38 | МАЙ//004.E | Номер готов к передаче в типографию | milestone | 0d | 2002-04-09 | 2002-04-09 | 37 | 0d |  |  |  |  |
